# Office Renovation

Schedule from MS Project, 2025-04-07 to 2025-06-20, 7 hours a day.

## Calendars

- Standard: Mon-Fri 09:00-12:00, 13:00-17:00; Sat-Sun off. Exceptions (off unless hours are given): 2025-04-18 to 2025-04-21 (Easter), 2025-04-25 (Anzac Day), 2025-05-05 (Labor day).
- Weekend work: Mon-Fri off; Sat-Sun 09:00-12:00, 13:00-17:00.

## Resources

| Resource |
| --- |
| Admin Assistant |
| Carpenter |
| Carpet Contractor |
| Fit-out Consultant |
| IT Consultant |
| Labourer |
| Management |
| Painter |
| Plastering Contractor |
| Project Manager |
| Staff |
| Cleaner |

## Schedule

| ID | WBS | Task | Type | Duration | Start | Finish | Predecessors | Total slack | Free slack | Deadline | Resources | Work |
| --- | --- | --- | --- | --- | --- | --- | --- | --- | --- | --- | --- | --- |
| 1 | 1 | **Planning & Research** |  | 14d | 2025-04-07 | 2025-04-29 |  | 4d |  |  |  | 63h |
| 2 | 1.1 | Develop Requirements Documentation |  | 1d | 2025-04-07 | 2025-04-07 |  | 4d | 0d | 2025-04-18 | Project Manager | 7h |
| 3 | 1.2 | Fit-Out Consultant Research & Engagement |  | 2d | 2025-04-08 | 2025-04-09 | 2 | 4d | 0d |  | Project Manager | 14h |
| 4 | 1.3 | IT Network Contractor Research & Engagement |  | 2d | 2025-04-10 | 2025-04-11 | 3 | 4d | 0d |  | Project Manager | 14h |
| 5 | 1.4 | Building Contractor Research & Engagement |  | 2d | 2025-04-14 | 2025-04-15 | 4 | 4d | 0d |  | Project Manager | 14h |
| 6 | 1.5 | Submit Requirements to Resources & Request Quotes |  | 1d | 2025-04-16 | 2025-04-16 | 5 | 4d | 0d |  | Project Manager | 7h |
| 7 | 1.6 | Quotes Received |  | 1d | 2025-04-29 | 2025-04-29 | 6FS+5d | 4d | 0d |  | Project Manager | 7h |
| 8 | 1.7 | Planning & Research Complete | milestone | 0d | 2025-04-29 | 2025-04-29 | 7 | 4d | 0d |  |  |  |
| 9 | 2 | **Management Approval** |  | 5d | 2025-04-30 | 2025-05-07 |  | 4d |  |  |  | 42h |
| 10 | 2.1 | Consolidate Quotes and develop proposal |  | 2d | 2025-04-30 | 2025-05-01 | 8 | 4d | 0d |  | Project Manager | 14h |
| 11 | 2.2 | Develop Project Plan & Durations |  | 2d | 2025-05-02 | 2025-05-06 | 10 | 4d | 0d |  | Project Manager | 14h |
| 12 | 2.3 | Submit Project Plan & Costs to Management |  | 1d | 2025-05-07 | 2025-05-07 | 11 | 4d | 0d |  | Management; Project Manager | 14h |
| 13 | 2.4 | Management Approval Received | milestone | 0d | 2025-05-07 | 2025-05-07 | 12 | 4d | 0d |  |  |  |
| 14 | 3 | **Refit Office** |  | 27d | 2025-05-08 | 2025-06-15 |  | 0d |  |  |  | 259h |
| 15 | 3.1 | Appoint Resources |  | 1d | 2025-05-08 | 2025-05-08 | 13 | 4d | 0d |  | Project Manager | 7h |
| 16 | 3.2 | Staff Briefing |  | 1d | 2025-05-09 | 2025-05-09 | 15 | 4d | 0d |  | Project Manager; Staff [700%] | 56h |
| 17 | 3.3 | **Fit-Out Consultations** |  | 5d | 2025-05-12 | 2025-05-16 |  | 4d |  |  |  | 70h |
| 18 | 3.3.1 | Design office space/structure plan |  | 1d | 2025-05-12 | 2025-05-12 | 16 | 4d | 0d |  | Fit-out Consultant; Project Manager | 14h |
| 19 | 3.3.2 | Select & Order Carpet |  | 1d | 2025-05-13 | 2025-05-13 | 18 | 16d | 0d |  | Fit-out Consultant; Project Manager | 14h |
| 20 | 3.3.3 | Select & Order Paint |  | 1d | 2025-05-14 | 2025-05-14 | 19 | 16d | 0d |  | Fit-out Consultant; Project Manager | 14h |
| 21 | 3.3.4 | Select & Order Office Furniture |  | 1d | 2025-05-15 | 2025-05-15 | 20 | 16d | 0d |  | Fit-out Consultant; Project Manager | 14h |
| 22 | 3.3.5 | Select & Order digital PBX |  | 1d | 2025-05-16 | 2025-05-16 | 21 | 20d | 15d |  | Fit-out Consultant; Project Manager | 14h |
| 23 | 3.4 | **IT consultations** |  | 12d | 2025-05-12 | 2025-05-27 |  | 4d |  |  |  | 28h |
| 24 | 3.4.1 | Design IT network and phone points map |  | 1d | 2025-05-12 | 2025-05-12 | 16 | 4d | 0d |  | IT Consultant | 7h |
| 25 | 3.4.2 | Select & Order New PCs |  | 1d | 2025-05-13 | 2025-05-13 | 24 | 13d | 2d |  | IT Consultant | 7h |
| 26 | 3.4.3 | New PCs Arrive |  | 0.5d | 2025-05-26 | 2025-05-26 | 25FS+10ed | 13d | 0d |  | Project Manager | 3.5h |
| 27 | 3.4.4 | Configure SOE on PCs |  | 1.5d | 2025-05-26 | 2025-05-27 | 26 | 13d |  |  | IT Consultant | 10.5h |

| ID | WBS | Task | Type | Duration | Start | Finish | Predecessors | Total slack | Calendar | Resources | Work |
| --- | --- | --- | --- | --- | --- | --- | --- | --- | --- | --- | --- |
| 28 | 3.5 | **Refit Office** |  | 20d | 2025-05-17 | 2025-06-15 |  | 0d |  |  | 98h |
| 29 | 3.5.1 | Erect New Walls |  | 2d | 2025-05-17 | 2025-05-18 | 18, 24 | 0d | Weekend work | Carpenter [200%] | 28h |
| 30 | 3.5.2 | Gyprock, Plaster & Finish |  | 2d | 2025-05-18 | 2025-05-24 | 29FS-1d | 0d | Weekend work | Plastering Contractor | 14h |
| 31 | 3.5.3 | Install Network & Phone Points |  | 1d | 2025-05-25 | 2025-05-25 | 30 | 0d | Weekend work | IT Consultant | 7h |
| 32 | 3.5.4 | Painting |  | 2d | 2025-05-31 | 2025-06-01 | 31 | 0d | Weekend work | Painter | 14h |
| 33 | 3.5.5 | Lay new carpets |  | 1d | 2025-06-07 | 2025-06-07 | 32 | 0d | Weekend work | Carpet Contractor | 7h |
| 34 | 3.5.6 | Install PBX hardware |  | 1d | 2025-06-08 | 2025-06-08 | 22, 33 | 1d | Weekend work | IT Consultant | 7h |
| 35 | 3.5.7 | Install New Furniture |  | 2d | 2025-06-08 | 2025-06-14 | 21, 33 | 0d | Weekend work | Labourer | 14h |
| 36 | 3.5.8 | Connect and install PCs and phones |  | 1d | 2025-06-15 | 2025-06-15 | 27, 34, 35 | 0d | Weekend work | IT Consultant | 7h |
| 37 | 3.5.9 | Refit Office Complete | milestone | 0d | 2025-06-15 | 2025-06-15 | 36 | 0d |  |  |  |
| 38 | 4 | **Office Move** |  | 30d | 2025-05-12 | 2025-06-20 |  | 0d |  |  | 472.5h |
| 39 | 4.1 | Order packing boxes |  | 0.5d | 2025-05-12 | 2025-05-12 | 16 | 24.5d |  | Admin Assistant | 3.5h |
| 40 | 4.2 | Staff Pack |  | 1d | 2025-06-16 | 2025-06-16 | 37, 39 | 0d |  | Project Manager; Staff [2000%] | 147h |
| 41 | 4.3 | Staff Move |  | 2d | 2025-06-17 | 2025-06-18 | 40 | 0d |  | Staff [2000%]; Labourer | 294h |
| 42 | 4.4 | Office cleaning |  | 2d | 2025-06-19 | 2025-06-20 | 41 | 0d |  | Cleaner [200%] | 28h |
| 43 | 4.5 | Office Move Complete | milestone | 0d | 2025-06-20 | 2025-06-20 | 42 | 0d |  |  |  |
