# Office Renovation

Schedule from MS Project, 2025-04-07 to 2025-06-04, 7 hours a day.

## Calendars

- Standard: Mon-Fri 09:00-12:00, 13:00-17:00; Sat-Sun off. Exceptions (off unless hours are given): 2025-04-18 to 2025-04-21 (Easter), 2025-04-25 (Anzac day), 2025-05-05 (Labor day).

## Schedule

| ID | WBS | Task | Type | Duration | Start | Finish | Predecessors | Total slack | Free slack |
| --- | --- | --- | --- | --- | --- | --- | --- | --- | --- |
| 1 | 1 | **Planning & Research** |  | 14d | 2025-04-07 | 2025-04-29 |  | 2d |  |
| 2 | 1.1 | Develop Requirements Documentation |  | 1d | 2025-04-07 | 2025-04-07 |  | 2d | 0d |
| 3 | 1.2 | Fit-Out Consultant Research & Engagement |  | 2d | 2025-04-08 | 2025-04-09 | 2 | 2d | 0d |
| 4 | 1.3 | IT Network Contractor Research & Engagement |  | 2d | 2025-04-10 | 2025-04-11 | 3 | 2d | 0d |
| 5 | 1.4 | Building Contractor Research & Engagement |  | 2d | 2025-04-14 | 2025-04-15 | 4 | 2d | 0d |
| 6 | 1.5 | Submit Requirements to Resources & Request Quotes |  | 1d | 2025-04-16 | 2025-04-16 | 5 | 2d | 0d |
| 7 | 1.6 | Quotes Received |  | 1d | 2025-04-29 | 2025-04-29 | 6FS+5d | 2d | 0d |
| 8 | 1.7 | Planning & Research Complete | milestone | 0d | 2025-04-29 | 2025-04-29 | 7 | 2d | 0d |
| 9 | 2 | **Management Approval** |  | 5d | 2025-04-30 | 2025-05-07 |  | 2d |  |
| 10 | 2.1 | Consolidate Quotes and develop proposal |  | 2d | 2025-04-30 | 2025-05-01 | 8 | 2d | 0d |
| 11 | 2.2 | Develop Project Plan & Durations |  | 2d | 2025-05-02 | 2025-05-06 | 10 | 2d | 0d |
| 12 | 2.3 | Submit Project Plan & Costs to Management |  | 1d | 2025-05-07 | 2025-05-07 | 11 | 2d | 0d |
| 13 | 2.4 | Management Approval Received | milestone | 0d | 2025-05-07 | 2025-05-07 | 12 | 2d | 0d |
| 14 | 3 | **Refit Office** |  | 15d | 2025-05-08 | 2025-05-28 |  | 0d |  |
| 15 | 3.1 | Appoint Resources |  | 1d | 2025-05-08 | 2025-05-08 | 13 | 2d | 0d |
| 16 | 3.2 | Staff Briefing |  | 1d | 2025-05-09 | 2025-05-09 | 15 | 2d | 0d |
| 17 | 3.3 | **Fit-Out Consultations** |  | 4d | 2025-05-12 | 2025-05-15 |  | 2d |  |
| 18 | 3.3.1 | Design office space/structure plan |  | 1d | 2025-05-12 | 2025-05-12 | 16 | 2d | 0d |
| 19 | 3.3.2 | Select & Order Carpet |  | 1d | 2025-05-13 | 2025-05-13 | 18 | 7d | 0d |
| 20 | 3.3.3 | Select & Order Paint |  | 1d | 2025-05-13 | 2025-05-13 | 19SS | 7d | 0d |
| 21 | 3.3.4 | Select & Order Office Furniture |  | 1d | 2025-05-14 | 2025-05-14 | 20 | 7d | 0d |
| 22 | 3.3.5 | Select & Order digital PBX |  | 1d | 2025-05-15 | 2025-05-15 | 21 | 7d | 4d |
| 23 | 3.4 | **IT consultations** |  | 12d | 2025-05-12 | 2025-05-27 |  | 0d |  |
| 24 | 3.4.1 | Design IT network and phone points map |  | 1d | 2025-05-12 | 2025-05-12 | 16 | 2d | 0d |
| 25 | 3.4.2 | Select & Order New PCs |  | 1d | 2025-05-13 | 2025-05-13 | 24 | 2d |  |
| 26 | 3.4.3 | New PCs Arrive |  | 0.5d | 2025-05-26 | 2025-05-26 | 25FS+10ed | 0d |  |
| 27 | 3.4.4 | Configure SOE on PCs |  | 1.5d | 2025-05-26 | 2025-05-27 | 26 | 0d |  |

| ID | WBS | Task | Type | Duration | Start | Finish | Predecessors | Total slack | Free slack |
| --- | --- | --- | --- | --- | --- | --- | --- | --- | --- |
| 28 | 3.5 | **Refit Office** |  | 12d | 2025-05-13 | 2025-05-28 |  | 0d |  |
| 29 | 3.5.1 | Erect New Walls |  | 2d | 2025-05-13 | 2025-05-14 | 18, 24 | 2d | 0d |
| 30 | 3.5.2 | Gyprock, Plaster & Finish |  | 2d | 2025-05-14 | 2025-05-15 | 29FS-1d | 2d | 0d |
| 31 | 3.5.3 | Install Network & Phone Points |  | 1d | 2025-05-16 | 2025-05-16 | 30 | 2d | 0d |
| 32 | 3.5.4 | Painting |  | 2d | 2025-05-19 | 2025-05-20 | 31 | 2d | 0d |
| 33 | 3.5.5 | Lay new carpets |  | 1d | 2025-05-21 | 2025-05-21 | 32 | 2d | 0d |
| 34 | 3.5.6 | Install PBX hardware |  | 1d | 2025-05-22 | 2025-05-22 | 22, 33 | 3d |  |
| 35 | 3.5.7 | Install New Furniture |  | 2d | 2025-05-22 | 2025-05-23 | 21, 33 | 2d |  |
| 36 | 3.5.8 | Connect and install PCs and phones |  | 1d | 2025-05-28 | 2025-05-28 | 27, 34, 35 | 0d |  |
| 37 | 3.5.9 | Refit Office Complete | milestone | 0d | 2025-05-28 | 2025-05-28 | 36 | 0d |  |
| 38 | 4 | **Office Move** |  | 18d | 2025-05-12 | 2025-06-04 |  | 0d |  |
| 39 | 4.1 | Order packing boxes |  | 0.5d | 2025-05-12 | 2025-05-12 | 16 | 12.5d |  |
| 40 | 4.2 | Staff Pack |  | 1d | 2025-05-29 | 2025-05-29 | 37, 39 | 0d |  |
| 41 | 4.3 | Staff Move |  | 2d | 2025-05-30 | 2025-06-02 | 40 | 0d |  |
| 42 | 4.4 | Office cleaning |  | 2d | 2025-06-03 | 2025-06-04 | 41 | 0d |  |
| 43 | 4.5 | Office Move Complete | milestone | 0d | 2025-06-04 | 2025-06-04 | 42 | 0d |  |
